# Тема9

Schedule from MS Project, 2009-09-07 to 2009-11-19, status date 2009-11-20, costs in р., A marks actual dates.
ТИУиЭ

## Calendars

- Стандартный: Mon-Fri 09:00-13:00, 14:00-18:00; Sat-Sun off. Exceptions (off unless hours are given): 2009-11-04 (День согласия и примирения).

## Resources

| Resource | Unit | Rate |
| --- | --- | --- |
| Постановщик |  | 312.5 |
| Программист1 |  | 406.25 |
| Программист2 |  | 437.5 |
| Бумага | пачка | 200 |
| Междугородные переговоры |  |  |
| CD-матрица | штука | 10 |
| Инженер по жокументации |  | 312.5 |

## Schedule

| ID | WBS | Task | Type | Duration | Start | Finish | Predecessors | Complete | Remaining | Baseline start | Baseline finish | Baseline duration | Total slack | Constraint | Deadline | Resources | Work | Actual work | Cost | Baseline cost | Actual cost |
| --- | --- | --- | --- | --- | --- | --- | --- | --- | --- | --- | --- | --- | --- | --- | --- | --- | --- | --- | --- | --- | --- |
| 1 | 1 | Начало реализации проекта | milestone | 0d | 2009-09-07 | 2009-09-07 |  |  |  | 2009-09-07 | 2009-09-07 | 0d | 12d |  |  |  |  |  |  |  |  |
| 2 | 2 | **Программирование** |  | 30.5d | 2009-09-07 A | 2009-10-19 |  | 99% | 0d | 2009-09-07 | 2009-10-13 | 27d | 21.96d |  |  |  | 288h | 288h | 117,105 | 116,730 | 116,480 |
| 3 | 2.1 | Постановка задачи |  | 10d | 2009-09-07 A | 2009-09-22 A | 1 | 100% |  | 2009-09-07 | 2009-09-22 | 10d |  |  |  | Постановщик; Бумага [1 пачка]; CD-матрица [0.25 штука]; Междугородные переговоры [0.2%] | 80h | 80h | 26,345 | 26,220 | 25,720 |
| 4 | 2.2 | Разработка интерфейса |  | 5.5d | 2009-09-23 A | 2009-09-30 A | 3 | 100% |  | 2009-09-23 | 2009-09-29 | 5d |  |  |  | Программист1; CD-матрица [0.62 штука]; Междугородные переговоры [0.5%] | 40h | 40h | 17,500 | 16,800 | 17,500 |
| 5 | 2.3 | Разработка модулей обработки данных |  | 8d | 2009-10-01 A | 2009-10-12 A | 4, 6 | 100% |  | 2009-10-02 | 2009-10-09 | 6d |  |  |  | Программист1; CD-матрица [0.75 штука] | 48h | 48h | 19,560 | 19,560 | 19,560 |
| 6 | 2.4 | Разработка структуры базы данных |  | 7d | 2009-09-23 A | 2009-10-01 A | 3 | 100% |  | 2009-09-23 | 2009-10-01 | 7d |  |  |  | Программист2; CD-матрица [0.88 штука]; Междугородные переговоры [0.2%] | 56h | 56h | 25,620 | 26,070 | 25,620 |
| 7 | 2.5 | Заполнение базы данных |  | 11.5d | 2009-10-02 A | 2009-10-19 A | 6 | 100% |  | 2009-10-02 | 2009-10-13 | 8d |  |  |  | Программист2; CD-матрица [1 штука] | 64h | 64h | 28,080 | 28,080 | 28,080 |
| 8 | 2.6 | Программирование завершено | milestone | 0d | 2009-10-19 | 2009-10-19 | 5, 7 |  |  | 2009-10-13 | 2009-10-13 | 0d | 10.5d |  |  |  |  |  |  |  |  |
| 9 | 3 | **Отладка** |  | 21.96d | 2009-10-19 A | 2009-11-19 |  | 82% | 3.99d | 2009-10-14 | 2009-11-12 | 21d | 0d |  |  |  | 400h | 344h | 160,350 | 160,350 | 141,550 |
| 10 | 3.1 | Отладка программного комплекса |  | 8d | 2009-10-19 A | 2009-11-02 A | 8 | 100% |  | 2009-10-14 | 2009-10-26 | 8d |  |  |  | Постановщик; Программист1; Программист2; CD-матрица [0.25 штука] | 120h | 120h | 46,350 | 46,350 | 46,350 |
| 11 | 3.2 | Тестирование и исправление ошибок |  | 12d | 2009-10-28 A | 2009-11-16 | 10 | 83% | 2d | 2009-10-27 | 2009-11-12 | 12d | 0d | finish no later than 2009-11-16 | 2009-11-16 | Постановщик; Программист1; Программист2; CD-матрица [0.25 штука] | 240h | 224h | 95,200 | 95,200 | 95,200 |
| 12 | 3.3 | Составление программной документации |  | 2d | 2009-11-03 | 2009-11-19 | 10 |  |  | 2009-10-27 | 2009-11-12 | 2d | 0d | as late as possible |  | Постановщик [50%]; CD-матрица [10 штука]; Междугородные переговоры [0.5%]; Программист1; Программист2 | 40h |  | 18,800 | 18,800 |  |
| 13 | 3.4 | Отладка завершена | milestone | 0d | 2009-11-19 | 2009-11-19 | 11, 12 |  |  | 2009-11-12 | 2009-11-12 | 0d | 0d |  |  |  |  |  |  |  |  |
| 14 | 4 | Конец проекта | milestone | 0d | 2009-11-19 | 2009-11-19 | 13 |  |  | 2009-11-12 | 2009-11-12 | 0d | 0d |  |  |  |  |  |  |  |  |
